# SUBPROYECTO A3 rev01

Schedule from Primavera P6, 2023-10-15 to 2024-04-27, data date 2023-10-15.

## Calendars

- 1T - 7x0 - 8 hr: Mon-Sun 08:00-16:00.

## Schedule

| ID | WBS | Activity | Type | Duration | Start | Finish | Predecessors | Total float | Free float | Constraint |
| --- | --- | --- | --- | --- | --- | --- | --- | --- | --- | --- |
|  | 0 | **HITOS** |  |  | 2023-10-15 | 2024-04-25 |  |  |  |  |
| A1000 |  | KICK OFF MEETING | milestone | 0d | 2023-10-15 | 2023-10-15 |  | 0d |  |  |
| A1010 |  | INICIO DEL SERVICIO | milestone | 0d | 2023-10-31 | 2023-10-31 | A1000 FS+16d | 0d |  |  |
| A1015 |  | INICIO DE EXCAVACIÓN | milestone | 0d | 2023-11-05 | 2023-11-05 | A1060 SS+5d | 1d | 0d |  |
| A1016 |  | INICIO DE RELLENO DE DIQUE | milestone | 0d | 2023-11-27 | 2023-11-27 |  | 153d |  | start on or after 2023-11-27 |
| A1020 |  | FIN DEL SERVICIO | milestone | 0d | 2024-04-25 | 2024-04-25 | A1200, A1760, A1780, A1070, A1050, A4020, A3850, A3790, A3780, A3740, A3730, A3640, A3630, A3580, A3560, A3550, A3530, A3470, A3450, A3400, A3260, A3160, A3140, A3130, A3080, A2930, A2880, A1900, A4920, A5190 | 0d |  |  |
|  | 1 | **DEFENSAS RIBEREÑAS** |  |  | 2023-10-31 | 2024-04-27 |  |  |  |  |
|  | 1 | **OBRAS PRELIMINARES** |  |  | 2023-11-02 | 2024-04-23 |  |  |  |  |
| A1030 |  | CARTEL DE IDENTIFICACIÓN OBRA 4.80 x 3.60 m. |  | 2d | 2023-11-02 | 2023-11-03 | A1060 SS+2d | 3d | 1d |  |
| A1040 |  | INSTALACIONES PROVISIONALES PARA LA OBRA |  | 169d | 2023-11-05 | 2024-04-21 | A1015, A1030 | 2d | 0d |  |
| A1050 |  | MANTENIMIENTO DE TRÁNSITO Y SEGURIDAD VIAL |  | 154d | 2023-11-22 | 2024-04-23 | A1100 | 2d |  |  |
|  | 2 | **TRABAJOS PRELIMINARES** |  |  | 2023-10-31 | 2024-04-27 |  |  |  |  |
| A1060 |  | MOVILIZACION DE EQUIPOS |  | 31d | 2023-10-31 | 2023-11-30 | A1010 | 1d | 0d |  |
| A1070 |  | TOPOGRAFÍA Y GEOREFERENCIACIÓN |  | 174d | 2023-11-02 | 2024-04-23 | A1060 SS+2d | 2d | 0d |  |
| A1080 |  | DESMOVILIZACION DE EQUIPOS |  | 23d | 2024-04-05 | 2024-04-27 | A1020 FF+2d | 0d |  |  |
|  | 3 | **MEJORAMIENTO DE VÍAS EXISTENTES** |  |  | 2023-11-05 | 2024-01-04 |  |  |  |  |
|  | 1 | **MOVIMIENTO DE TIERRAS** |  |  | 2023-11-05 | 2023-11-21 |  |  |  |  |
| A1090 |  | ROCE Y LIMPIEZA DE MALEZA |  | 17d | 2023-11-05 | 2023-11-21 | A1015 SS, A1040 SS | 2d | 0d |  |
| A1100 |  | MEJORAMIENTO DE VIAS EXISTENTES |  | 17d | 2023-11-05 | 2023-11-21 | A1090 SS | 2d | 0d |  |
|  | 2 | **REPOSICIÓN DE ESTRUCTURAS** |  |  | 2023-11-25 | 2023-12-29 |  |  |  |  |
| A1150 |  | DEMOLICIÓN DE ESTRUCTURAS EXISTENTES |  | 2d | 2023-11-25 | 2023-11-26 | A1070 SS+23d | 112d | 0d |  |
| A1160 |  | REPOSICIÓN DE PASE DE AGUA TUBO HDPE Ø=18" |  | 2d | 2023-11-28 | 2023-11-29 | A1150 SS+3d | 112d | 0d |  |
| A1170 |  | REPOSICIÓN DE PASE DE AGUA TUBO HDPE Ø=36" |  | 2d | 2023-11-28 | 2023-11-29 | A1160 SS | 112d | 0d |  |
| A1180 |  | SUMINISTRO Y MONTAJE DE PANELES DE C°A° 1.6mx1.0mx0.20m EN PASE DE AGUA |  | 30d | 2023-11-30 | 2023-12-29 | A1170 SS+2d | 112d | 0d |  |
| A1190 |  | SUMINISTRO Y MONTAJE DE PANELES DE C°A° 2.20mx1.0mx0.20m EN PASE DE AGUA |  | 30d | 2023-11-30 | 2023-12-29 | A1180 SS | 112d | 0d |  |

| ID | WBS | Activity | Duration | Start | Finish | Predecessors | Total float | Free float | Filtro |
| --- | --- | --- | --- | --- | --- | --- | --- | --- | --- |
|  | 4 | **CABEZAL DE ENTRADA Y SALIDA** |  | 2023-12-30 | 2024-01-04 |  |  |  |  |
| A1210 |  | ENCOFRADO Y DESENCOFRADO RECTO | 3d | 2023-12-30 | 2024-01-01 | A1190 | 112d | 0d |  |
| A1200 |  | CONCRETOS | 3d | 2024-01-02 | 2024-01-04 | A1210 | 112d |  |  |
|  | 4 | **DESCOLMATACIÓN DE CAUCE Y OBRAS AUXILIARES** |  | 2023-11-07 | 2024-04-11 |  |  |  |  |
|  | 1 | **DESBROCE Y DESCOLMATACIÓN** |  | 2023-11-07 | 2024-02-11 |  |  |  |  |
| A1220 |  | DESBROCE Y LIMPIEZA EN ZONA NO BOSCOSA | 76d | 2023-11-07 | 2024-01-21 | A1015 FS+1d, A1010 FS+7d | 0d |  | Excavación |
| A1230 |  | DESCOLMATACIÓN DE CAUCE NATURAL DEL RÍO LACRAMARCA - DIQUE A3-D-01 | 10d | 2023-11-07 | 2023-11-16 | A1220 SS | 0d |  | Excavación |
| A1880 |  | DESCOLMATACIÓN DE CAUCE NATURAL DEL RÍO LACRAMARCA - DIQUE A3-I-01 | 32d | 2023-11-07 | 2023-12-08 | A1230 SS | 85d | 0d | Excavación |
| A1870 |  | DESCOLMATACIÓN DE CAUCE NATURAL DEL RÍO LACRAMARCA - DIQUE A3-D-02 | 53d | 2023-11-17 | 2024-01-08 | A1230 | 74d | 0d | Excavación |
| A1890 |  | DESCOLMATACIÓN DE CAUCE NATURAL DEL RÍO LACRAMARCA - DIQUE A3-I-02 | 20d | 2023-12-09 | 2023-12-28 | A1880 | 85d | 11d | Excavación |
| A1900 |  | DESCOLMATACIÓN DE CAUCE NATURAL DEL RÍO LACRAMARCA - DIQUE A3-I-03 | 34d | 2024-01-09 | 2024-02-11 | A1890, A1870 | 74d |  | Excavación |
|  | 2 | **DESVIO DEL CAUCE** |  | 2023-11-07 | 2024-04-11 |  |  |  |  |
| A5200 |  | CONFORMACIÓN DE DESVIO EN CAUCE DE RÍO | 68d | 2023-11-07 | 2024-01-13 | A1015 FS+2d | 8d | 0d |  |
| A5210 |  | RELLENO NO ESTRUCTURAL CON MATERIAL PROPIO | 89d | 2024-01-14 | 2024-04-11 | A5200 | 16d |  |  |
|  | 5 | **DIQUES DE TIERRA COMPACTADA CON ENROCADO** |  | 2023-11-12 | 2024-04-25 |  |  |  |  |
|  | 1 | **DIQUE DE TIERRA COMPACTADA A3-D-01** |  | 2023-11-12 | 2024-03-30 |  |  |  |  |
|  | 1 | **SIN AFECTACIÓN A3-D-01** |  | 2023-11-12 | 2023-11-26 |  |  |  |  |
| A4210 |  | EXCAVACIÓN EN TERRENO NATURAL CON EQUIPO | 4d | 2023-11-12 | 2023-11-15 | A1230 SS+5d, A5200 SS | 3d | 0d | Excavación |
| A4220 |  | EXCAVACIÓN DE UÑA CON EQUIPO | 2d | 2023-11-12 | 2023-11-13 | A4210 SS | 4d | 1d | Excavación |
| A4230 |  | PERFILADO Y COMPACTACIÓN EN ZONA DE CORTE | 8d | 2023-11-13 | 2023-11-20 | A4210 SS+1d | 3d | 0d |  |
| A4240 |  | PREPARACIÓN DE FUNDACIÓN DE CUERPO DE DIQUE | 1d | 2023-11-13 | 2023-11-13 | A4230 SS | 3d | 0d |  |
| A4250 |  | CONFORMACIÓN DE CUERPO DE DIQUE CON MATERIAL PROPIO | 2d | 2023-11-15 | 2023-11-16 | A4220 SS+2d, A4240 SS+2d | 3d | 0d | Relleno |
| A4260 |  | GEOTEXTIL NO TEJIDO 400 G/M2, INC. COLOCACIÓN | 2d | 2023-11-17 | 2023-11-18 | A4250 SS+2d | 3d | 0d |  |
| A4270 |  | COLOCACION Y ACOMODO DE ROCA EN UÑA DE DIQUE | 2d | 2023-11-18 | 2023-11-19 | A4260 SS+1d | 3d | 0d | Roca |
| A4280 |  | COLOCACION Y ACOMODO DE ROCA EN TALUD DE DIQUE | 4d | 2023-11-20 | 2023-11-23 | A4270 SS+2d | 3d | 0d | Roca |
| A4290 |  | CONFORMACIÓN DE CORONA DE DIQUE CON MATERIAL PROPIO | 2d | 2023-11-25 | 2023-11-26 | A4280 FF+3d | 3d | 0d | Relleno |

| ID | WBS | Activity | Duration | Start | Finish | Predecessors | Total float | Free float | Filtro |
| --- | --- | --- | --- | --- | --- | --- | --- | --- | --- |
|  | 2 | **CON AFECTACIÓN A3-D-01** |  | 2024-03-07 | 2024-03-30 |  |  |  |  |
| A4300 |  | EXCAVACIÓN EN TERRENO NATURAL CON EQUIPO | 10d | 2024-03-07 | 2024-03-16 | A4830 | 3d | 0d | Excavación |
| A4310 |  | EXCAVACIÓN DE UÑA CON EQUIPO | 11d | 2024-03-08 | 2024-03-18 | A4300 SS+1d | 8d | 5d | Excavación |
| A4320 |  | PERFILADO Y COMPACTACIÓN EN ZONA DE CORTE | 12d | 2024-03-08 | 2024-03-19 | A4300 SS+1d | 3d | 0d |  |
| A4330 |  | PREPARACIÓN DE FUNDACIÓN DE CUERPO DE DIQUE | 8d | 2024-03-13 | 2024-03-20 | A4320 SS+5d | 3d | 0d |  |
| A4340 |  | CONFORMACIÓN DE CUERPO DE DIQUE CON MATERIAL PROPIO | 4d | 2024-03-18 | 2024-03-21 | A4310 SS+5d, A4330 SS+5d | 3d | 0d | Relleno |
| A4350 |  | GEOTEXTIL NO TEJIDO 400 G/M2, INC. COLOCACIÓN | 4d | 2024-03-20 | 2024-03-23 | A4340 SS+2d | 3d | 0d |  |
| A4360 |  | COLOCACION Y ACOMODO DE ROCA EN UÑA DE DIQUE | 3d | 2024-03-21 | 2024-03-23 | A4350 SS+1d | 3d | 0d | Roca |
| A4370 |  | COLOCACION Y ACOMODO DE ROCA EN TALUD DE DIQUE | 6d | 2024-03-22 | 2024-03-27 | A4360 SS+1d | 3d | 0d | Roca |
| A4380 |  | CONFORMACIÓN DE CORONA DE DIQUE CON MATERIAL PROPIO | 3d | 2024-03-28 | 2024-03-30 | A4370 FF+3d | 3d | 0d | Relleno |
|  | 2 | **DIQUE DE TIERRA COMPACTADA A3-D-02** |  | 2023-11-27 | 2024-04-22 |  |  |  |  |
|  | 1 | **SIN AFECTACIÓN A3-D-02** |  | 2023-11-27 | 2024-01-04 |  |  |  |  |
| A4660 |  | EXCAVACIÓN EN TERRENO NATURAL CON EQUIPO | 16d | 2023-11-27 | 2023-12-12 | A4290 | 3d | 0d | Excavación |
| A4670 |  | EXCAVACIÓN DE UÑA CON EQUIPO | 15d | 2023-11-28 | 2023-12-12 | A4660 SS+1d | 9d | 6d | Excavación |
| A4680 |  | PERFILADO Y COMPACTACIÓN EN ZONA DE CORTE | 23d | 2023-11-28 | 2023-12-20 | A4660 SS+1d | 3d | 0d |  |
| A4690 |  | PREPARACIÓN DE FUNDACIÓN DE CUERPO DE DIQUE | 18d | 2023-12-04 | 2023-12-21 | A4680 SS+6d | 3d | 0d |  |
| A4700 |  | CONFORMACIÓN DE CUERPO DE DIQUE CON MATERIAL PROPIO | 17d | 2023-12-06 | 2023-12-22 | A4670 SS+2d, A4690 SS+2d | 3d | 0d | Relleno |
| A4710 |  | GEOTEXTIL NO TEJIDO 400 G/M2, INC. COLOCACIÓN | 16d | 2023-12-08 | 2023-12-23 | A4700 SS+2d | 3d | 0d |  |
| A4720 |  | COLOCACION Y ACOMODO DE ROCA EN UÑA DE DIQUE | 23d | 2023-12-09 | 2023-12-31 | A4710 SS+1d | 3d | 0d | Roca |
| A4730 |  | COLOCACION Y ACOMODO DE ROCA EN TALUD DE DIQUE | 22d | 2023-12-11 | 2024-01-01 | A4720 SS+2d | 3d | 0d | Roca |
| A4740 |  | CONFORMACIÓN DE CORONA DE DIQUE CON MATERIAL PROPIO | 4d | 2024-01-01 | 2024-01-04 | A4730 FF+3d | 3d | 0d | Relleno |
|  | 2 | **CON AFECTACIÓN A3-D-02** |  | 2024-01-05 | 2024-03-06 |  |  |  |  |
| A4750 |  | EXCAVACIÓN EN TERRENO NATURAL CON EQUIPO | 25d | 2024-01-05 | 2024-01-29 | A4740 | 3d | 0d | Excavación |
| A4760 |  | EXCAVACIÓN DE UÑA CON EQUIPO | 27d | 2024-01-08 | 2024-02-03 | A4750 SS+3d | 25d | 22d | Excavación |
| A4770 |  | PERFILADO Y COMPACTACIÓN EN ZONA DE CORTE | 30d | 2024-01-09 | 2024-02-07 | A4750 SS+4d | 3d | 0d |  |
| A4780 |  | PREPARACIÓN DE FUNDACIÓN DE CUERPO DE DIQUE | 10d | 2024-01-30 | 2024-02-08 | A4770 SS+21d | 3d | 0d |  |
| A4790 |  | CONFORMACIÓN DE CUERPO DE DIQUE CON MATERIAL PROPIO | 10d | 2024-02-01 | 2024-02-10 | A4760 SS+2d, A4780 SS+2d | 3d | 0d | Relleno |
| A4800 |  | GEOTEXTIL NO TEJIDO 400 G/M2, INC. COLOCACIÓN | 13d | 2024-02-02 | 2024-02-14 | A4790 SS+1d | 3d | 0d |  |
| A4810 |  | COLOCACION Y ACOMODO DE ROCA EN UÑA DE DIQUE | 31d | 2024-02-03 | 2024-03-04 | A4800 SS+1d | 3d | 0d | Roca |
| A4820 |  | COLOCACION Y ACOMODO DE ROCA EN TALUD DE DIQUE | 28d | 2024-02-05 | 2024-03-03 | A4810 SS+2d | 3d | 0d | Roca |
| A4830 |  | CONFORMACIÓN DE CORONA DE DIQUE CON MATERIAL PROPIO | 4d | 2024-03-03 | 2024-03-06 | A4820 FF+3d | 3d | 0d | Relleno |

| ID | WBS | Activity | Duration | Start | Finish | Predecessors | Total float | Free float | Filtro |
| --- | --- | --- | --- | --- | --- | --- | --- | --- | --- |
|  | 3 | **POR LIBERAR A3-D-02** |  | 2024-03-31 | 2024-04-22 |  |  |  |  |
| A4840 |  | EXCAVACIÓN EN TERRENO NATURAL CON EQUIPO | 4d | 2024-03-31 | 2024-04-03 | A4380 | 3d | 0d | Excavación |
| A4850 |  | EXCAVACIÓN DE UÑA CON EQUIPO | 4d | 2024-04-03 | 2024-04-06 | A4840 SS+3d | 6d | 3d | Excavación |
| A4860 |  | PERFILADO Y COMPACTACIÓN EN ZONA DE CORTE | 6d | 2024-04-03 | 2024-04-08 | A4840 SS+3d | 3d | 0d |  |
| A4870 |  | PREPARACIÓN DE FUNDACIÓN DE CUERPO DE DIQUE | 5d | 2024-04-06 | 2024-04-10 | A4860 SS+3d | 3d | 0d |  |
| A4880 |  | CONFORMACIÓN DE CUERPO DE DIQUE CON MATERIAL PROPIO | 5d | 2024-04-07 | 2024-04-11 | A4850 SS+1d, A4870 SS+1d | 3d | 0d | Relleno |
| A4890 |  | GEOTEXTIL NO TEJIDO 400 G/M2, INC. COLOCACIÓN | 5d | 2024-04-10 | 2024-04-14 | A4880 SS+3d | 3d | 0d |  |
| A4900 |  | COLOCACION Y ACOMODO DE ROCA EN UÑA DE DIQUE | 6d | 2024-04-12 | 2024-04-17 | A4890 SS+2d | 3d | 0d | Roca |
| A4910 |  | COLOCACION Y ACOMODO DE ROCA EN TALUD DE DIQUE | 6d | 2024-04-14 | 2024-04-19 | A4900 SS+2d | 3d | 0d | Roca |
| A4920 |  | CONFORMACIÓN DE CORONA DE DIQUE CON MATERIAL PROPIO | 4d | 2024-04-19 | 2024-04-22 | A4910 FF+3d | 3d |  | Relleno |
|  | 3 | **DIQUE DE TIERRA COMPACTADA A3-I-01** |  | 2023-11-13 | 2024-03-09 |  |  |  |  |
|  | 1 | **SIN AFECTACIÓN A3-I-01** |  | 2023-11-13 | 2023-12-02 |  |  |  |  |
| A1440 |  | EXCAVACIÓN EN TERRENO NATURAL CON EQUIPO | 6d | 2023-11-13 | 2023-11-18 | A1230 SS+6d | 0d |  | Excavación |
| A1450 |  | EXCAVACIÓN DE UÑA CON EQUIPO | 4d | 2023-11-16 | 2023-11-19 | A1440 SS+3d | 0d |  | Excavación |
| A1460 |  | PERFILADO Y COMPACTACIÓN EN ZONA DE CORTE | 5d | 2023-11-16 | 2023-11-20 | A1440 SS+1d, A1450 SS | 0d |  |  |
| A1520 |  | PREPARACIÓN DE FUNDACIÓN DE CUERPO DE DIQUE | 3d | 2023-11-19 | 2023-11-21 | A1460 SS+3d | 0d |  |  |
| A1470 |  | CONFORMACIÓN DE CUERPO DE DIQUE CON MATERIAL PROPIO | 5d | 2023-11-20 | 2023-11-24 | A1520 SS+1d | 0d |  | Relleno |
| A1490 |  | GEOTEXTIL NO TEJIDO 400 G/M2, INC. COLOCACIÓN | 3d | 2023-11-22 | 2023-11-24 | A1470 SS+2d | 0d |  |  |
| A1500 |  | COLOCACION Y ACOMODO DE ROCA EN UÑA DE DIQUE | 3d | 2023-11-24 | 2023-11-26 | A1490 SS+2d | 0d |  | Roca |
| A1510 |  | COLOCACION Y ACOMODO DE ROCA EN TALUD DE DIQUE | 5d | 2023-11-26 | 2023-11-30 | A1500 SS+2d | 0d |  | Roca |
| A1480 |  | CONFORMACIÓN DE CORONA DE DIQUE CON MATERIAL PROPIO | 3d | 2023-11-30 | 2023-12-02 | A1510 FF+2d | 0d |  | Relleno |
|  | 3 | **CON AFECTACIÓN A3-I-01** |  | 2024-02-26 | 2024-03-09 |  |  |  |  |
| A4480 |  | EXCAVACIÓN EN TERRENO NATURAL CON EQUIPO | 5d | 2024-02-26 | 2024-03-01 | A5100 | 0d |  | Excavación |
| A4490 |  | EXCAVACIÓN DE UÑA CON EQUIPO | 3d | 2024-02-27 | 2024-02-29 | A4480 SS+1d | 0d |  | Excavación |
| A4500 |  | PERFILADO Y COMPACTACIÓN EN ZONA DE CORTE | 4d | 2024-02-27 | 2024-03-01 | A4480 SS+1d, A4490 SS | 0d |  |  |
| A4510 |  | PREPARACIÓN DE FUNDACIÓN DE CUERPO DE DIQUE | 4d | 2024-02-27 | 2024-03-01 | A4500 SS | 0d |  |  |
| A4520 |  | CONFORMACIÓN DE CUERPO DE DIQUE CON MATERIAL PROPIO | 4d | 2024-02-28 | 2024-03-02 | A4510 SS+1d | 0d |  | Relleno |
| A4530 |  | GEOTEXTIL NO TEJIDO 400 G/M2, INC. COLOCACIÓN | 3d | 2024-03-01 | 2024-03-03 | A4520 SS+2d | 0d |  |  |
| A4540 |  | COLOCACION Y ACOMODO DE ROCA EN UÑA DE DIQUE | 3d | 2024-03-03 | 2024-03-05 | A4530 SS+2d | 0d |  | Roca |
| A4550 |  | COLOCACION Y ACOMODO DE ROCA EN TALUD DE DIQUE | 5d | 2024-03-04 | 2024-03-08 | A4540 SS+1d | 0d |  | Roca |
| A4560 |  | CONFORMACIÓN DE CORONA DE DIQUE CON MATERIAL PROPIO | 3d | 2024-03-07 | 2024-03-09 | A4550 FF+1d | 0d |  | Relleno |

| ID | WBS | Activity | Duration | Start | Finish | Predecessors | Total float | Free float | Filtro |
| --- | --- | --- | --- | --- | --- | --- | --- | --- | --- |
|  | 4 | **DIQUE DE TIERRA COMPACTADA A3-I-02** |  | 2024-03-10 | 2024-04-05 |  |  |  |  |
|  | 2 | **Sector por Liberar - Km 20+980 - km 21+300** |  | 2024-03-10 | 2024-04-05 |  |  |  |  |
| A4390 |  | EXCAVACIÓN EN TERRENO NATURAL CON EQUIPO | 14d | 2024-03-10 | 2024-03-23 | A4560 | 0d |  | Excavación |
| A4400 |  | EXCAVACIÓN DE UÑA CON EQUIPO | 13d | 2024-03-11 | 2024-03-23 | A4390 SS+1d | 1d | 0d | Excavación |
| A4410 |  | PERFILADO Y COMPACTACIÓN EN ZONA DE CORTE | 10d | 2024-03-15 | 2024-03-24 | A4390 SS+5d | 0d |  |  |
| A4470 |  | PREPARACIÓN DE FUNDACIÓN DE CUERPO DE DIQUE | 5d | 2024-03-21 | 2024-03-25 | A4410 FF+1d | 3d | 2d |  |
| A4420 |  | CONFORMACIÓN DE CUERPO DE DIQUE CON MATERIAL PROPIO | 3d | 2024-03-24 | 2024-03-26 | A4470 SS+1d, A4400 | 1d |  | Relleno |
| A4440 |  | GEOTEXTIL NO TEJIDO 400 G/M2, INC. COLOCACIÓN | 5d | 2024-03-25 | 2024-03-29 | A4420 SS, A4410 | 0d |  |  |
| A4450 |  | COLOCACION Y ACOMODO DE ROCA EN UÑA DE DIQUE | 6d | 2024-03-25 | 2024-03-30 | A4440 SS | 0d |  | Roca |
| A4460 |  | COLOCACION Y ACOMODO DE ROCA EN TALUD DE DIQUE | 11d | 2024-03-25 | 2024-04-04 | A4450 SS | 0d |  | Roca |
| A4430 |  | CONFORMACIÓN DE CORONA DE DIQUE CON MATERIAL PROPIO | 6d | 2024-03-31 | 2024-04-05 | A4460 FF+1d | 0d |  | Relleno |
|  | 5 | **DIQUE DE TIERRA COMPACTADA A3-I-03** |  | 2023-12-03 | 2024-04-25 |  |  |  |  |
|  | 1 | **SIN AFECTACIÓN A3-I-03** |  | 2023-12-03 | 2024-01-24 |  |  |  |  |
| A4930 |  | EXCAVACIÓN EN TERRENO NATURAL CON EQUIPO | 25d | 2023-12-03 | 2023-12-27 | A1480 | 0d |  | Excavación |
| A4950 |  | PERFILADO Y COMPACTACIÓN EN ZONA DE CORTE | 30d | 2023-12-04 | 2024-01-02 | A4930 SS+1d | 0d |  |  |
| A4940 |  | EXCAVACIÓN DE UÑA CON EQUIPO | 23d | 2023-12-07 | 2023-12-29 | A4930 SS+4d | 13d |  | Excavación |
| A4960 |  | PREPARACIÓN DE FUNDACIÓN DE CUERPO DE DIQUE | 12d | 2023-12-20 | 2023-12-31 | A4950 SS+16d | 0d |  |  |
| A4970 |  | CONFORMACIÓN DE CUERPO DE DIQUE CON MATERIAL PROPIO | 12d | 2023-12-22 | 2024-01-02 | A4940 SS+2d, A4960 SS+2d | 0d |  | Relleno |
| A4980 |  | GEOTEXTIL NO TEJIDO 400 G/M2, INC. COLOCACIÓN | 13d | 2023-12-24 | 2024-01-05 | A4970 SS+2d | 0d |  |  |
| A4990 |  | COLOCACION Y ACOMODO DE ROCA EN UÑA DE DIQUE | 30d | 2023-12-25 | 2024-01-23 | A4980 SS+1d | 0d |  | Roca |
| A5000 |  | COLOCACION Y ACOMODO DE ROCA EN TALUD DE DIQUE | 28d | 2023-12-27 | 2024-01-23 | A4990 SS+2d | 0d |  | Roca |
| A5010 |  | CONFORMACIÓN DE CORONA DE DIQUE CON MATERIAL PROPIO | 13d | 2024-01-12 | 2024-01-24 | A5000 FF+1d | 0d |  | Relleno |
|  | 3 | **CON AFECTACIÓN A3-I-03** |  | 2024-01-25 | 2024-02-25 |  |  |  |  |
| A5020 |  | EXCAVACIÓN EN TERRENO NATURAL CON EQUIPO | 10d | 2024-01-25 | 2024-02-03 | A5010 | 0d |  | Excavación |
| A5030 |  | EXCAVACIÓN DE UÑA CON EQUIPO | 9d | 2024-01-27 | 2024-02-04 | A5020 SS+2d | 6d |  | Excavación |
| A5040 |  | PERFILADO Y COMPACTACIÓN EN ZONA DE CORTE | 11d | 2024-01-28 | 2024-02-07 | A5020 SS+3d | 0d |  |  |
| A5050 |  | PREPARACIÓN DE FUNDACIÓN DE CUERPO DE DIQUE | 8d | 2024-02-02 | 2024-02-09 | A5040 SS+5d | 0d |  |  |
| A5060 |  | CONFORMACIÓN DE CUERPO DE DIQUE CON MATERIAL PROPIO | 4d | 2024-02-07 | 2024-02-10 | A5030 SS+5d, A5050 SS+5d | 0d |  | Relleno |
| A5070 |  | GEOTEXTIL NO TEJIDO 400 G/M2, INC. COLOCACIÓN | 5d | 2024-02-09 | 2024-02-13 | A5060 SS+2d | 0d |  |  |
| A5080 |  | COLOCACION Y ACOMODO DE ROCA EN UÑA DE DIQUE | 12d | 2024-02-10 | 2024-02-21 | A5070 SS+1d | 0d |  | Roca |
| A5090 |  | COLOCACION Y ACOMODO DE ROCA EN TALUD DE DIQUE | 11d | 2024-02-12 | 2024-02-22 | A5080 SS+2d | 0d |  | Roca |
| A5100 |  | CONFORMACIÓN DE CORONA DE DIQUE CON MATERIAL PROPIO | 5d | 2024-02-21 | 2024-02-25 | A5090 FF+3d | 0d |  | Relleno |

| ID | WBS | Activity | Duration | Start | Finish | Predecessors | Total float | Free float | Filtro |
| --- | --- | --- | --- | --- | --- | --- | --- | --- | --- |
|  | 2 | **POR LIBERAR A3-I-03** |  | 2024-04-06 | 2024-04-25 |  |  |  |  |
| A5110 |  | EXCAVACIÓN EN TERRENO NATURAL CON EQUIPO | 6d | 2024-04-06 | 2024-04-11 | A4430 | 0d |  | Excavación |
| A5120 |  | EXCAVACIÓN DE UÑA CON EQUIPO | 5d | 2024-04-07 | 2024-04-11 | A5110 SS+1d | 4d | 0d | Excavación |
| A5130 |  | PERFILADO Y COMPACTACIÓN EN ZONA DE CORTE | 8d | 2024-04-07 | 2024-04-14 | A5110 SS+1d | 0d |  |  |
| A5140 |  | PREPARACIÓN DE FUNDACIÓN DE CUERPO DE DIQUE | 6d | 2024-04-11 | 2024-04-16 | A5130 SS+4d | 0d |  |  |
| A5150 |  | CONFORMACIÓN DE CUERPO DE DIQUE CON MATERIAL PROPIO | 4d | 2024-04-14 | 2024-04-17 | A5120 SS+3d, A5140 SS+3d | 0d |  | Relleno |
| A5160 |  | GEOTEXTIL NO TEJIDO 400 G/M2, INC. COLOCACIÓN | 4d | 2024-04-16 | 2024-04-19 | A5150 SS+2d | 0d |  |  |
| A5170 |  | COLOCACION Y ACOMODO DE ROCA EN UÑA DE DIQUE | 8d | 2024-04-17 | 2024-04-24 | A5160 SS+1d | 0d |  | Roca |
| A5180 |  | COLOCACION Y ACOMODO DE ROCA EN TALUD DE DIQUE | 7d | 2024-04-19 | 2024-04-25 | A5170 SS+2d | 0d |  | Roca |
| A5190 |  | CONFORMACIÓN DE CORONA DE DIQUE CON MATERIAL PROPIO | 3d | 2024-04-23 | 2024-04-25 | A5180 SS+4d | 0d |  | Relleno |
|  | 6 | **RAMPAS** |  | 2024-03-09 | 2024-04-16 |  |  |  |  |
|  | 1 | **A3-RA-D-01** |  | 2024-03-09 | 2024-03-14 |  |  |  |  |
| A1710 |  | EXCAVACIÓN EN TERRENO NATURAL CON EQUIPO | 3d | 2024-03-09 | 2024-03-11 | A4550 | 40d | 0d | Excavación |
| A1720 |  | CONFORMACIÓN DE CUERPO DE RAMPA CON MATERIAL PROPIO | 3d | 2024-03-12 | 2024-03-14 | A1710 | 40d | 0d | Relleno |
| A1730 |  | CONFORMACIÓN DE CORONACIÓN DE RAMPA | 3d | 2024-03-12 | 2024-03-14 | A1720 SS | 40d | 31d | Relleno |
|  | 2 | **A3-RA-I-01** |  | 2024-04-12 | 2024-04-16 |  |  |  |  |
| A1740 |  | EXCAVACIÓN EN TERRENO NATURAL CON EQUIPO | 3d | 2024-04-12 | 2024-04-14 | A5120 | 9d | 0d | Excavación |
| A1750 |  | CONFORMACIÓN DE CUERPO DE RAMPA CON MATERIAL PROPIO | 2d | 2024-04-15 | 2024-04-16 | A1740 | 9d | 0d | Relleno |
| A1760 |  | CONFORMACIÓN DE CORONACIÓN DE RAMPA | 2d | 2024-04-15 | 2024-04-16 | A1750 SS, A1730 | 9d |  | Relleno |
|  | 2 | **OBRAS DE ARTE** |  | 2023-11-06 | 2024-03-18 |  |  |  |  |
|  | 1 | **CAPTACIÓN A3-CP-23-95** |  | 2023-11-21 | 2024-03-18 |  |  |  |  |
|  | 1 | **MOVIMIENTO DE TIERRAS** |  | 2023-11-21 | 2024-01-07 |  |  |  |  |
| A2770 |  | EXCAVACIÓN ESTRUCTURAL PARA OBRAS DE ARTE | 6d | 2023-11-21 | 2023-11-26 | A3390 | 38d | 0d |  |
| A2780 |  | RELLENO ESTRUCTURAL PARA OBRAS DE ARTE, CON MATERIAL PROPIO | 5d | 2024-01-03 | 2024-01-07 | A2800 FS+12d | 90d | 1d |  |

| ID | WBS | Activity | Duration | Start | Finish | Predecessors | Total float | Free float |
| --- | --- | --- | --- | --- | --- | --- | --- | --- |
|  | 2 | **OBRAS DE CONCRETO** |  | 2023-11-27 | 2023-12-21 |  |  |  |
| A2790 |  | CONCRETO f'c=100 kg/cm2 | 3d | 2023-11-27 | 2023-11-29 | A2770 | 50d | 0d |
| A2810 |  | CONCRETO CICLÓPEO f'c=280 kg/cm2 + 30% P.G. | 3d | 2023-11-30 | 2023-12-02 | A2790 | 50d | 0d |
| A2830 |  | ACERO DE REFUERZO fy=4200 kg/cm2 | 13d | 2023-12-03 | 2023-12-15 | A2810 | 50d | 0d |
| A2820 |  | ENCOFRADO Y DESENCOFRADO RECTO | 10d | 2023-12-07 | 2023-12-16 | A2830 FF+1d | 53d | 0d |
| A2800 |  | CONCRETO f'c=280 kg/cm2 | 12d | 2023-12-10 | 2023-12-21 | A2820 SS+3d | 55d | 0d |
|  | 3 | **ESTRUCTURAS METALICAS** |  | 2024-01-03 | 2024-01-17 |  |  |  |
| A2840 |  | COMPUERTA METALICA PLANA DESLIZANTE DE 1.0x1.0m | 3d | 2024-01-03 | 2024-01-05 | A2800 FS+12d | 99d | 0d |
| A2850 |  | REJILLA DE 1.00x1.00m CON VARILLA DE 1/2" CADA 6,25cm | 3d | 2024-01-06 | 2024-01-08 | A2840 | 99d | 0d |
| A2860 |  | BARANDA DE FIERRO GALVANIZADO 1 1/2" | 3d | 2024-01-09 | 2024-01-11 | A2850 | 99d | 0d |
| A2870 |  | ESCALERA TIPO GATO | 3d | 2024-01-12 | 2024-01-14 | A2860 | 99d | 0d |
| A2880 |  | TAPA METALICA CIRCULAR DN600 MM | 3d | 2024-01-15 | 2024-01-17 | A2870 | 99d |  |
|  | 4 | **TUBERIAS** |  | 2023-11-27 | 2024-01-23 |  |  |  |
| A2890 |  | EXCAVACIÓN ESTRUCTURAL PARA OBRAS DE ARTE (Buzones) | 3d | 2023-11-27 | 2023-11-29 | A2770 | 38d | 0d |
| A2900 |  | EXCAVACIÓN DE ZANJA | 25d | 2023-11-30 | 2023-12-24 | A2890 | 38d | 0d |
| A2920 |  | CAMA DE ARENA | 25d | 2023-12-03 | 2023-12-27 | A2900 SS+3d | 93d | 0d |
| A2940 |  | CONCRETO f'c=100 kg/cm2 (Buzones) | 3d | 2023-12-03 | 2023-12-05 | A2900 SS+3d, A2790 | 60d | 10d |
| A2990 |  | SUMINISTRO E INSTALACIÓN DE TUBERÍA GRP DN600 mm SN2500 | 25d | 2023-12-04 | 2023-12-28 | A2920 SS+1d | 93d | 0d |
| A2980 |  | ACERO DE REFUERZO fy=4200 kg/cm2 (Buzones) | 4d | 2023-12-16 | 2023-12-19 | A2940, A2830 | 50d | 0d |
| A2960 |  | ENCOFRADO Y DESENCOFRADO RECTO | 5d | 2023-12-20 | 2023-12-24 | A2820, A2980 | 50d | 0d |
| A2970 |  | ENCOFRADO Y DESENCOFRADO CURVO | 5d | 2023-12-20 | 2023-12-24 | A2960 SS | 50d | 0d |
| A2950 |  | CONCRETO f'c=280 kg/cm2 (Buzones) | 3d | 2023-12-25 | 2023-12-27 | A2970, A2800 | 52d | 0d |
| A2930 |  | RELLENO COMÚN PARA ZANJAS | 26d | 2023-12-29 | 2024-01-23 | A2990 | 93d |  |
| A2910 |  | RELLENO ESTRUCTURAL PARA OBRAS DE ARTE CON MATERIAL PROPIO (Buzones) | 3d | 2024-01-09 | 2024-01-11 | A2950 FS+12d, A2780 | 89d | 0d |

| ID | WBS | Activity | Duration | Start | Finish | Predecessors | Total float | Free float |
| --- | --- | --- | --- | --- | --- | --- | --- | --- |
|  | 5 | **CANAL** |  | 2023-12-25 | 2024-02-29 |  |  |  |
| A3000 |  | EXCAVACIÓN ESTRUCTURAL PARA OBRAS DE ARTE | 6d | 2023-12-25 | 2023-12-30 | A2900 | 38d | 0d |
| A3020 |  | COLOCACIÓN DE CONCRETO f'c=100 kg/cm2 | 4d | 2023-12-31 | 2024-01-03 | A2940, A3000 | 38d | 0d |
| A3050 |  | ACERO DE REFUERZO fy=4200 kg/cm2 | 28d | 2024-01-04 | 2024-01-31 | A2980, A3020 | 38d | 0d |
| A3040 |  | ENCOFRADO Y DESENCOFRADO RECTO | 52d | 2024-01-06 | 2024-02-26 | A2970, A3050 SS+2d | 38d | 0d |
| A3030 |  | COLOCACIÓN DE CONCRETO f'c=280 kg/cm2 | 53d | 2024-01-08 | 2024-02-29 | A2950 SS, A3040 SS+2d | 38d | 0d |
| A3060 |  | JUNTA WATER STOP SIN BULBO 150 mm | 53d | 2024-01-08 | 2024-02-29 | A3030 SS | 53d | 3d |
| A3010 |  | RELLENO ESTRUCTURAL PARA CANALES, CON MATERIAL PROPIO | 13d | 2024-01-12 | 2024-01-24 | A2910 | 89d | 51d |
|  | 6 | **OBRAS DE DESCARGA** |  | 2023-12-31 | 2024-03-18 |  |  |  |
| A3070 |  | EXCAVACIÓN ESTRUCTURAL PARA OBRAS DE ARTE | 3d | 2023-12-31 | 2024-01-02 | A3000 | 87d | 1d |
| A3090 |  | CONCRETO f'c=100 kg/cm2 | 3d | 2024-01-04 | 2024-01-06 | A3070, A3020 | 86d | 25d |
| A3120 |  | ACERO DE REFUERZO fy=4200 kg/cm2 | 3d | 2024-02-01 | 2024-02-03 | A3090, A3050 | 61d | 23d |
| A3110 |  | ENCOFRADO Y DESENCOFRADO RECTO | 3d | 2024-02-27 | 2024-02-29 | A3120, A3040 | 38d | 0d |
| A3100 |  | CONCRETO f'c=280 kg/cm2 | 3d | 2024-03-01 | 2024-03-03 | A3110, A3030 | 38d | 0d |
| A3130 |  | JUNTA WATER STOP SIN BULBO 150 mm | 3d | 2024-03-04 | 2024-03-06 | A3100, A3060 | 50d |  |
| A3080 |  | RELLENO ESTRUCTURAL PARA OBRAS DE ARTE CON MATERIAL PROPIO | 3d | 2024-03-16 | 2024-03-18 | A3100 FS+12d, A3010 | 38d |  |
| A3140 |  | COMPUERTA METALICA PLANA DESLIZANTE | 3d | 2024-03-16 | 2024-03-18 | A3100 FS+12d | 38d |  |
|  | 2 | **CAPTACIÓN A3-CP-21-05** |  | 2023-11-09 | 2024-02-06 |  |  |  |
|  | 1 | **MOVIMIENTO DE TIERRAS** |  | 2023-11-09 | 2023-12-28 |  |  |  |
| A3150 |  | EXCAVACIÓN ESTRUCTURAL PARA OBRAS DE ARTE | 4d | 2023-11-09 | 2023-11-12 | A1070 SS+7d | 38d | 0d |
| A3160 |  | RELLENO ESTRUCTURAL PARA OBRAS DE ARTE, CON MATERIAL PROPIO | 5d | 2023-12-24 | 2023-12-28 | A3180 FS+12d | 119d |  |
|  | 2 | **OBRAS DE CONCRETO** |  | 2023-11-13 | 2023-12-11 |  |  |  |
| A3170 |  | CONCRETO f'c=100 kg/cm2 | 3d | 2023-11-13 | 2023-11-15 | A3150 | 79d | 0d |
| A3190 |  | CONCRETO CICLÓPEO f'c=280 kg/cm2 + 30% P.G. | 3d | 2023-11-16 | 2023-11-18 | A3170 | 79d | 0d |
| A3210 |  | ACERO DE REFUERZO fy=4200 kg/cm2 | 21d | 2023-11-19 | 2023-12-09 | A3190 | 79d | 0d |
| A3200 |  | ENCOFRADO Y DESENCOFRADO RECTO | 15d | 2023-11-25 | 2023-12-09 | A3210 SS+6d | 82d | 0d |
| A3180 |  | CONCRETO f'c=280 kg/cm2 | 11d | 2023-12-01 | 2023-12-11 | A3200 SS+6d | 109d | 0d |

| ID | WBS | Activity | Duration | Start | Finish | Predecessors | Total float | Free float |
| --- | --- | --- | --- | --- | --- | --- | --- | --- |
|  | 3 | **ESTRUCTURAS METALICAS** |  | 2023-12-24 | 2024-01-07 |  |  |  |
| A3220 |  | COMPUERTA METALICA PLANA DESLIZANTE DE 1.0x1.0m | 3d | 2023-12-24 | 2023-12-26 | A3180 FS+12d | 109d | 0d |
| A3230 |  | REJILLA DE 1.00x1.00m CON VARILLA DE 1/2 CADA 6,25cm | 3d | 2023-12-27 | 2023-12-29 | A3220 | 109d | 0d |
| A3240 |  | BARANDA DE FIERRO GALVANIZADO 1 1/2" | 3d | 2023-12-30 | 2024-01-01 | A3230 | 109d | 0d |
| A3250 |  | ESCALERA TIPO GATO | 3d | 2024-01-02 | 2024-01-04 | A3240 | 109d | 0d |
| A3260 |  | TAPA METALICA CIRCULAR DN600 MM | 3d | 2024-01-05 | 2024-01-07 | A3250 | 109d |  |
|  | 4 | **TUBERIA** |  | 2023-11-13 | 2024-01-02 |  |  |  |
| A3270 |  | EXCAVACIÓN ESTRUCTURAL PARA OBRAS DE ARTE (Buzones) | 3d | 2023-11-13 | 2023-11-15 | A3150 | 38d | 0d |
| A3280 |  | EXCAVACIÓN DE ZANJA | 3d | 2023-11-16 | 2023-11-18 | A3270 | 143d | 0d |
| A3330 |  | CONCRETO f'c=100 kg/cm2 (Buzones) | 3d | 2023-11-16 | 2023-11-18 | A3270, A3170 | 100d | 2d |
| A3300 |  | CAMA DE ARENA | 3d | 2023-11-19 | 2023-11-21 | A3280 | 143d | 0d |
| A3380 |  | SUMINISTRO E INSTALACIÓN DE TUBERÍA GRP DN600 mm SN2500 | 3d | 2023-11-22 | 2023-11-24 | A3300 | 143d | 0d |
| A3310 |  | RELLENO SELECCIONADO PARA ZANJAS CON MATERIAL PROPIO | 3d | 2023-11-25 | 2023-11-27 | A3320 SS | 143d | 64d |
| A3320 |  | RELLENO COMÚN PARA ZANJAS | 3d | 2023-11-25 | 2023-11-27 | A3380 | 143d | 0d |
| A3370 |  | ACERO DE REFUERZO fy=4200 kg/cm2 | 3d | 2023-12-10 | 2023-12-12 | A3330, A3210 | 79d | 0d |
| A3350 |  | ENCOFRADO Y DESENCOFRADO RECTO | 3d | 2023-12-13 | 2023-12-15 | A3370, A3200 | 79d | 0d |
| A3360 |  | ENCOFRADO Y DESENCOFRADO CURVO | 3d | 2023-12-13 | 2023-12-15 | A3350 SS | 79d | 0d |
| A3340 |  | CONCRETO f'c=280 kg/cm2 (Buzones) | 3d | 2023-12-16 | 2023-12-18 | A3360, A3180 | 105d | 0d |
| A3290 |  | RELLENO ESTRUCTURAL PARA OBRAS DE ARTE CON MATERIAL PROPIO | 3d | 2023-12-31 | 2024-01-02 | A3340 FS+12d | 107d | 28d |
|  | 5 | **CANALES** |  | 2023-11-16 | 2024-02-06 |  |  |  |
| A3390 |  | EXCAVACIÓN ESTRUCTURAL PARA OBRAS DE ARTE | 5d | 2023-11-16 | 2023-11-20 | A3270 | 38d | 0d |
| A3410 |  | COLOCACIÓN DE CONCRETO f'c=100 kg/cm2 | 3d | 2023-11-21 | 2023-11-23 | A3390, A3330 | 98d | 19d |
| A3440 |  | ACERO DE REFUERZO fy=4200 kg/cm2 | 12d | 2023-12-13 | 2023-12-24 | A3410, A3370 | 79d | 0d |
| A3430 |  | ENCOFRADO Y DESENCOFRADO | 29d | 2023-12-16 | 2024-01-13 | A3440 SS+3d, A3360 | 79d | 0d |
| A3420 |  | COLOCACIÓN DE CONCRETO f'c=280 kg/cm2 | 5d | 2024-01-14 | 2024-01-18 | A3430, A3340 | 79d | 0d |
| A3450 |  | JUNTA WATER STOP SIN BULBO 150 mm | 3d | 2024-01-14 | 2024-01-16 | A3420 SS | 100d |  |
| A3400 |  | RELLENO ESTRUCTURAL PARA CANALES, CON MATERIAL PROPIO | 7d | 2024-01-31 | 2024-02-06 | A3420 FS+12d, A3290, A3310 | 79d |  |

| ID | WBS | Activity | Duration | Start | Finish | Predecessors | Total float | Free float |
| --- | --- | --- | --- | --- | --- | --- | --- | --- |
|  | 3 | **RETORNO A3-OA-RE-D-21-55** |  | 2023-11-06 | 2023-12-29 |  |  |  |
|  | 1 | **MOVIMIENTO DE TIERRAS** |  | 2023-11-06 | 2023-12-25 |  |  |  |
| A3460 |  | EXCAVACIÓN ESTRUCTURAL PARA OBRAS DE ARTE | 3d | 2023-11-06 | 2023-11-08 | A1070 SS+4d | 118d | 0d |
| A3470 |  | RELLENO ESTRUCTURAL PARA OBRAS DE ARTE, CON MATERIAL PROPIO | 3d | 2023-12-23 | 2023-12-25 | A3490 FS+12d | 122d |  |
|  | 2 | **OBRAS DE CONCRETO** |  | 2023-11-09 | 2023-12-10 |  |  |  |
| A3480 |  | CONCRETO f'c=100 kg/cm2 | 3d | 2023-11-09 | 2023-11-11 | A3460 | 118d | 0d |
| A3500 |  | CONCRETO CICLÓPEO f'c=280 kg/cm2 + 30% P.G. | 5d | 2023-11-12 | 2023-11-16 | A3480 | 118d | 0d |
| A3520 |  | ACERO DE REFUERZO fy=4200 kg/cm2 | 24d | 2023-11-12 | 2023-12-05 | A3500 SS | 118d | 0d |
| A3510 |  | ENCOFRADO Y DESENCOFRADO | 18d | 2023-11-18 | 2023-12-05 | A3520 SS+6d | 118d | 0d |
| A3490 |  | CONCRETO f'c=280 kg/cm2 | 5d | 2023-12-06 | 2023-12-10 | A3510 | 118d | 0d |
| A3530 |  | JUNTA WATER STOP SIN BULBO 150 mm | 5d | 2023-12-06 | 2023-12-10 | A3490 SS | 137d |  |
|  | 3 | **ESTRUCTURAS METALICAS** |  | 2023-12-23 | 2023-12-29 |  |  |  |
| A3540 |  | COMPUERTA METALICA PLANA DESLIZANTE DE 1.0x1.6 m | 4d | 2023-12-23 | 2023-12-26 | A3490 FS+12d | 118d | 0d |
| A3550 |  | BARANDA DE FIERRO GALVANIZADO 1 1/2" | 3d | 2023-12-27 | 2023-12-29 | A3540 | 118d |  |
|  | 4 | **REPOSICIÓN DE CANALES** |  | 2023-11-22 | 2024-03-14 |  |  |  |
|  | 1 | **REPOSICIÓN DE CANAL 1** |  | 2023-12-13 | 2024-03-14 |  |  |  |
|  | 1 | **MOVIMIENTO DE TIERRAS** |  | 2023-12-13 | 2024-01-24 |  |  |  |
| A3560 |  | DEMOLICIÓN DE ESTRUCTURAS EXISTENTES | 17d | 2023-12-13 | 2023-12-29 | A4660 | 42d | 0d |
| A3580 |  | RELLENO ESTRUCTURAL PARA OBRAS DE ARTE CON MATERIAL PROPIO | 39d | 2023-12-17 | 2024-01-24 | A4660 FS+4d | 92d |  |
| A3570 |  | EXCAVACIÓN EN TERRENO NATURAL CON EQUIPO | 36d | 2023-12-19 | 2024-01-23 | A3560 SS+6d | 42d | 0d |
|  | 2 | **OBRAS DE CONCRETO** |  | 2023-12-26 | 2024-03-14 |  |  |  |
| A3610 |  | CONCRETO f'c=100 kg/cm2 | 36d | 2023-12-26 | 2024-01-30 | A3570 SS+7d | 42d | 0d |
| A3600 |  | ACERO DE REFUERZO fy=4200 kg/cm2 | 70d | 2023-12-29 | 2024-03-07 | A3610 SS+3d | 42d | 0d |
| A3590 |  | ENCOFRADO Y DESENCOFRADO RECTO | 63d | 2024-01-05 | 2024-03-07 | A3600 SS+7d | 42d | 0d |
| A3620 |  | CONCRETO f'c=280 kg/cm2 | 54d | 2024-01-19 | 2024-03-12 | A3590 SS+14d | 42d | 0d |
| A3630 |  | JUNTA WATER STOP 6" | 54d | 2024-01-19 | 2024-03-12 | A3620 SS | 44d |  |
| A3640 |  | MAMPOSTERIA DE PIEDRA, e=20cm, ACABADO CARA VISTA | 2d | 2024-03-13 | 2024-03-14 | A3620 | 42d |  |

| ID | WBS | Activity | Duration | Start | Finish | Predecessors | Total float | Free float |
| --- | --- | --- | --- | --- | --- | --- | --- | --- |
|  | 2 | **REPOSICIÓN DE CANAL 3** |  | 2023-11-22 | 2024-01-16 |  |  |  |
|  | 1 | **MOVIMIENTO DE TIERRAS** |  | 2023-11-22 | 2023-12-20 |  |  |  |
| A3650 |  | DEMOLICIÓN DE ESTRUCTURAS EXISTENTES | 10d | 2023-11-22 | 2023-12-01 | A4210 FS+6d | 100d | 0d |
| A3660 |  | EXCAVACIÓN EN TERRENO NATURAL CON EQUIPO | 4d | 2023-12-14 | 2023-12-17 | A3650 FS+12d | 100d | 0d |
| A3670 |  | RELLENO ESTRUCTURAL PARA OBRAS DE ARTE CON MATERIAL PROPIO | 3d | 2023-12-18 | 2023-12-20 | A3660 | 100d | 0d |
|  | 2 | **OBRAS DE CONCRETO** |  | 2023-12-21 | 2024-01-16 |  |  |  |
| A3710 |  | CONCRETO f'c=100 kg/cm2 | 4d | 2023-12-21 | 2023-12-24 | A3670 | 100d | 0d |
| A3700 |  | MALLA ELECTROSOLDADA DE DN6mm EN CUADRICULA 15x15 cm | 15d | 2023-12-25 | 2024-01-08 | A3710 | 100d | 0d |
| A3680 |  | ENCOFRADO Y DESENCOFRADO PARA REVESTIMIENTO DE CANALES (CERCHAS) | 12d | 2023-12-28 | 2024-01-08 | A3700 SS+3d | 100d | 0d |
| A3690 |  | ENCOFRADO Y DESENCOFRADO RECTO | 12d | 2023-12-28 | 2024-01-08 | A3680 SS | 100d | 0d |
| A3730 |  | SELLO DE JUNTA CONSTRUCCIÓN CON MATERIAL ELASTOMÉRICO | 10d | 2023-12-28 | 2024-01-06 | A3680 SS | 110d |  |
| A3720 |  | CONCRETO f'c=280 kg/cm2 | 5d | 2024-01-09 | 2024-01-13 | A3690 | 100d | 0d |
| A3740 |  | MAMPOSTERIA DE PIEDRA, e=20cm, ACABADO CARA VISTA | 3d | 2024-01-14 | 2024-01-16 | A3720 | 100d |  |
|  | 5 | **REPOSICIÓN SIFON INOPERATIVO** |  | 2023-12-08 | 2024-01-16 |  |  |  |
| A3750 |  | DEMOLICIÓN DE ESTRUCTURAS EXISTENTES | 3d | 2023-12-08 | 2023-12-10 | A1230, A1880 FF+2d | 100d | 0d |
| A3760 |  | EXCAVACIÓN ESTRUCTURAL PARA OBRAS DE ARTE | 10d | 2023-12-11 | 2023-12-20 | A3750 | 100d | 0d |
| A3770 |  | COLOCACIÓN CAMA DE ARENA | 3d | 2023-12-21 | 2023-12-23 | A3760 | 109d | 0d |
| A3810 |  | CONCRETO f'c=100 kg/cm2 | 3d | 2023-12-21 | 2023-12-23 | A3760 | 100d | 0d |
| A3800 |  | TUBERÍAS DE 14" HDPE SDR21 DN 355mm | 6d | 2023-12-24 | 2023-12-29 | A3770 | 109d | 0d |
| A3840 |  | ACERO DE REFUERZO fy=4200 kg/cm2 | 3d | 2023-12-24 | 2023-12-26 | A3810 | 100d | 0d |
| A3850 |  | CODOS HDPE DE 14" DN 355mm | 6d | 2023-12-24 | 2023-12-29 | A3800 SS | 118d |  |
| A3830 |  | ENCOFRADO Y DESENCOFRADO RECTO | 3d | 2023-12-27 | 2023-12-29 | A3840 | 100d | 0d |
| A3790 |  | RELLENO COMÚN | 9d | 2023-12-30 | 2024-01-07 | A3800 | 109d |  |
| A3820 |  | CONCRETO f'c=280 kg/cm2 | 3d | 2023-12-30 | 2024-01-01 | A3830 | 100d | 0d |
| A3780 |  | RELLENO ESTRUCTURAL PARA OBRAS DE ARTE CON MATERIAL PROPIO | 3d | 2024-01-14 | 2024-01-16 | A3820 FS+12d | 100d |  |

| ID | WBS | Activity | Duration | Start | Finish | Predecessors | Total float | Free float | Filtro |
| --- | --- | --- | --- | --- | --- | --- | --- | --- | --- |
|  | 3 | **ARQUITECTURA Y PAISAJISMO** |  | 2024-01-05 | 2024-03-22 |  |  |  |  |
|  | 1 | **OBRAS PRELIMINARES** |  | 2024-01-05 | 2024-03-22 |  |  |  |  |
| A3860 |  | MOVILIZACIÓN DE EQUIPOS Y HERRAMIENTAS (ARQUITECTURA Y PAISAJISMO) | 2d | 2024-01-05 | 2024-01-06 | A4740 | 34d | 0d |  |
| A3870 |  | TRAZO Y REPLANTEO PRELIMINAR | 2d | 2024-01-07 | 2024-01-08 | A3860 | 34d | 0d |  |
| A4020 |  | DEMOVILIZACIÓN DE EQUIPOS Y HERRAMIENTAS (ARQUITECTURA Y PAISAJISMO) | 2d | 2024-03-21 | 2024-03-22 | A4010 FS+4d, A3900 | 34d |  |  |
|  | 2 | **MOVIMIENTO DE TIERRAS** |  | 2024-01-09 | 2024-01-25 |  |  |  |  |
| A3880 |  | EXCAVACIÓN MANUAL PARA INSTALACIÓN DE BORDILLOS Y CIMENTACIONES | 2d | 2024-01-09 | 2024-01-10 | A3870 | 34d | 0d |  |
| A3900 |  | ELIMINACION DE MATERIAL EXCEDENTE (DME´S) | 17d | 2024-01-09 | 2024-01-25 | A3880 SS | 89d | 55d |  |
| A3890 |  | EXCAVACIÓN PARA MEJORAMIENTO DE SUELO CON TIERRA VEGETAL | 15d | 2024-01-11 | 2024-01-25 | A3880 | 34d | 0d |  |
|  | 3 | **PAVIMENTOS, RECUBRIMIENTOS Y BORDILLOS** |  | 2024-01-26 | 2024-02-05 |  |  |  |  |
| A3910 |  | PISO DE GRAVILLA | 2d | 2024-01-26 | 2024-01-27 | A3890 | 34d | 0d |  |
| A3920 |  | RECUBRIMIENTO DE PIEDRA DEL LUGAR e=0.05cm | 4d | 2024-01-28 | 2024-01-31 | A3910 | 34d | 0d |  |
| A3930 |  | BORDILLOS DE PIEDRA DEL LUGAR | 5d | 2024-02-01 | 2024-02-05 | A3920 | 34d | 0d |  |
|  | 4 | **MOBILIARIOS, BARANDAS Y ESCALERAS** |  | 2024-02-06 | 2024-03-14 |  |  |  |  |
| A3940 |  | ESCALERA DE CONCRETO SOBRE ENROCADO, CIMENTACION Y ANCLAJE | 10d | 2024-02-06 | 2024-02-15 | A3930 | 34d | 0d |  |
| A3950 |  | BARANDA DE MADERA EUCALIPTO CON SOGA, INCLUYE CIMENTACIÓN | 4d | 2024-02-16 | 2024-02-19 | A3940 | 34d | 0d |  |
| A3960 |  | TACHOS DE BASURA, INCLUYE CIMENTACIÓN | 3d | 2024-02-20 | 2024-02-22 | A3950 | 34d | 0d |  |
| A3970 |  | BANCAS DE CONCRETO, INCLUYE CIMENTACIÓN | 10d | 2024-02-23 | 2024-03-03 | A3960 | 34d | 0d |  |
| A3980 |  | POSTES DE ILUMINACIÓN, INCLUYE LUMINARIA Y CIMENTACIÓN | 5d | 2024-03-04 | 2024-03-08 | A3970 | 34d | 0d |  |
| A3990 |  | SEÑALETICA INFORMATIVA | 3d | 2024-03-09 | 2024-03-11 | A3980 | 34d | 0d |  |
| A4000 |  | BOLARDOS DE PIEDRA | 3d | 2024-03-12 | 2024-03-14 | A3990 | 34d | 0d |  |
|  | 5 | **INSTALACIÓN DE ALCORQUES** |  | 2024-03-15 | 2024-03-16 |  |  |  |  |
| A4010 |  | ALCORQUES DE PIEDRA DE CANTO RODADO PARA ARBOLES | 2d | 2024-03-15 | 2024-03-16 | A4000 | 34d | 0d |  |
|  | 4 | **PROGRAMA DE CIERRE DE OBRA** |  | 2023-11-07 | 2024-04-22 |  |  |  |  |
| A1770 |  | ACONDICIONAMIENTO DE DEPOSITOS DE MATERIALES EXCEDENTES (DME) | 160d | 2023-11-07 | 2024-04-14 | A1220 SS | 3d | 0d | Excavación |
| A1780 |  | RESTAURACIÓN DE ÁREAS DE INSTALACIONES PROVISIONALES | 8d | 2024-04-15 | 2024-04-22 | A1770 | 3d |  |  |
